# Template for Specialty Build

Schedule from MS Project, 2007-06-28 to 2007-07-03.
Novant Health, Inc

## Calendars

- Standard: Mon-Fri 08:00-12:00, 13:00-17:00; Sat-Sun off.

## Resources

| Resource |
| --- |
| Matt |

## Schedule

| ID | WBS | Task | Duration | Start | Finish | Predecessors | Total slack | Free slack |
| --- | --- | --- | --- | --- | --- | --- | --- | --- |
| 1 | 1 | **Speciaty Build** | 4d | 2007-06-28 08:00 | 2007-07-03 17:00 |  | 0d |  |
| 2 | 1.1 | Call Processing Text Templates | 4h | 2007-06-28 08:00 | 2007-06-28 12:00 |  | 3.5d |  |
| 3 | 1.2 | Clinical Desktop Views | 8h | 2007-06-28 08:00 | 2007-06-28 17:00 |  | 3d |  |
| 4 | 1.3 | **Allergy Favorites** | 0.06d | 2007-06-28 08:00 | 2007-06-28 08:30 |  | 3.94d |  |
| 5 | 1.3.1 | Medication Allergies | 0.5h | 2007-06-28 08:00 | 2007-06-28 08:30 |  | 3.94d |  |
| 6 | 1.3.2 | Non-Medication Allergies | 0.5h | 2007-06-28 08:00 | 2007-06-28 08:30 |  | 3.94d |  |
| 7 | 1.4 | **Problem Favorites** | 0.12d | 2007-06-28 08:00 | 2007-06-28 09:00 |  | 3.88d |  |
| 8 | 1.4.1 | Active Problems | 1h | 2007-06-28 08:00 | 2007-06-28 09:00 |  | 3.88d |  |
| 9 | 1.4.2 | Family Hx | 1h | 2007-06-28 08:00 | 2007-06-28 09:00 |  | 3.88d |  |
| 10 | 1.4.3 | Past Medical Hx | 1h | 2007-06-28 08:00 | 2007-06-28 09:00 |  | 3.88d |  |
| 11 | 1.4.4 | Social Hx | 1h | 2007-06-28 08:00 | 2007-06-28 09:00 |  | 3.88d |  |
| 12 | 1.4.5 | Surgical Hx | 1h | 2007-06-28 08:00 | 2007-06-28 09:00 |  | 3.88d |  |
| 13 | 1.5 | Build Text Templates | 4h | 2007-06-28 08:00 | 2007-06-28 12:00 |  | 3.5d |  |
| 14 | 1.6 | Charge Code Display Names | 4h | 2007-06-28 08:00 | 2007-06-28 12:00 |  | 3.5d |  |
| 15 | 1.7 | CPT Modifier Groups | 1h | 2007-06-28 08:00 | 2007-06-28 09:00 |  | 3.88d |  |
| 16 | 1.8 | Diagnosis Code Display Names | 4h | 2007-06-28 08:00 | 2007-06-28 12:00 |  | 3.5d |  |
| 17 | 1.9 | Charge Diagnosis Sub-Groups | 4h | 2007-06-28 08:00 | 2007-06-28 12:00 |  | 3.5d |  |
| 18 | 1.10 | Define Exploding Sets | 4h | 2007-06-28 08:00 | 2007-06-28 12:00 |  | 3d | 0d |
| 19 | 1.11 | Assign Exploding Sets | 4h | 2007-06-28 13:00 | 2007-06-28 17:00 | 18 | 3d |  |
| 20 | 1.12 | Define Charge Groups | 4h | 2007-06-28 08:00 | 2007-06-28 12:00 |  | 3.5d |  |
| 21 | 1.13 | Define Charge Sub-Groups | 4h | 2007-06-28 08:00 | 2007-06-28 12:00 |  | 3.5d |  |
| 22 | 1.14 | Diagnosis Favorites | 8h | 2007-06-28 08:00 | 2007-06-28 17:00 |  | 3d |  |
| 23 | 1.15 | Procedure Charge Favorites | 8h | 2007-06-28 08:00 | 2007-06-28 17:00 |  | 3d |  |
| 24 | 1.16 | Visit Charge Favorites | 8h | 2007-06-28 08:00 | 2007-06-28 17:00 |  | 3d |  |
| 25 | 1.17 | Charge Visit Sub-Groups | 4h | 2007-06-28 08:00 | 2007-06-28 12:00 |  | 3.5d |  |
| 26 | 1.18 | Document Types | 16h | 2007-06-28 08:00 | 2007-06-29 17:00 |  | 2d |  |
| 27 | 1.19 | Define Problem Note Forms | 4h | 2007-06-28 08:00 | 2007-06-28 12:00 |  | 3.5d |  |
| 28 | 1.20 | Create Problem Note Forms | 32h | 2007-06-28 08:00 | 2007-07-03 17:00 |  | 0d |  |
| 29 | 1.21 | Define Note Input Templates | 16h | 2007-06-28 08:00 | 2007-06-29 17:00 |  | 2d |  |
| 30 | 1.22 | Create Note Input Templates | 16h | 2007-06-28 08:00 | 2007-06-29 17:00 |  | 2d |  |
| 31 | 1.23 | Define Note Output Templates | 16h | 2007-06-28 08:00 | 2007-06-29 17:00 |  | 2d |  |
| 32 | 1.24 | Create Note Output Templates | 16h | 2007-06-28 08:00 | 2007-06-29 17:00 |  | 2d |  |
| 33 | 1.25 | Create Note Text Templates | 16h | 2007-06-28 08:00 | 2007-06-29 17:00 |  | 2d |  |

| ID | WBS | Task | Duration | Start | Finish | Total slack |
| --- | --- | --- | --- | --- | --- | --- |
| 34 | 1.26 | **Order Favorites** | 0.25d | 2007-06-28 08:00 | 2007-06-28 10:00 | 3.75d |
| 35 | 1.26.1 | Labs | 2h | 2007-06-28 08:00 | 2007-06-28 10:00 | 3.75d |
| 36 | 1.26.2 | Rad | 2h | 2007-06-28 08:00 | 2007-06-28 10:00 | 3.75d |
| 37 | 1.26.3 | Procedures | 2h | 2007-06-28 08:00 | 2007-06-28 10:00 | 3.75d |
| 38 | 1.26.4 | Supplies | 2h | 2007-06-28 08:00 | 2007-06-28 10:00 | 3.75d |
| 39 | 1.27 | Flowsheet Definitions | 1h | 2007-06-28 08:00 | 2007-06-28 09:00 | 3.88d |
| 40 | 1.28 | Create Flowsheets | 8h | 2007-06-28 08:00 | 2007-06-28 17:00 | 3d |
| 41 | 1.29 | Vital Views | 1h | 2007-06-28 08:00 | 2007-06-28 09:00 | 3.88d |
| 42 | 1.30 | **Medication Favorites** | 0.12d | 2007-06-28 08:00 | 2007-06-28 09:00 | 3.88d |
| 43 | 1.30.1 | Medication Hx | 1h | 2007-06-28 08:00 | 2007-06-28 09:00 | 3.88d |
| 44 | 1.30.2 | Medication Admin | 1h | 2007-06-28 08:00 | 2007-06-28 09:00 | 3.88d |
| 45 | 1.30.3 | Rx | 1h | 2007-06-28 08:00 | 2007-06-28 09:00 | 3.88d |
| 46 | 1.30.4 | Immunization | 1h | 2007-06-28 08:00 | 2007-06-28 09:00 | 3.88d |
| 47 | 1.31 | Document Security | 2h | 2007-06-28 08:00 | 2007-06-28 10:00 | 3.75d |
